# United Nations DAP Project Gantt Chart Revision 9.1.2004

Schedule from MS Project, 2004-08-18 to 2005-05-19, costs in $.
Entium Corporation

## Calendars

- Standard: Mon-Fri 08:00-12:00, 13:00-17:00; Sat-Sun off. Exceptions (off unless hours are given): 2004-09-06, 2004-11-12, 2004-11-25 to 2004-11-26, 2004-12-24 to 2004-12-31, 2005-01-17, 2005-02-14.

## Resources

| Resource | Rate |
| --- | --- |
| Fred Diers | 250 |
| Christine Ardern | 170 |
| Sean Rickert | 90 |
| Jim Mernin | 170 |
| Dhurjati Mueller |  |
| WG-ARM Members |  |
| UNPOs |  |
| DAP Coordinators |  |

## Schedule

| ID | WBS | Task | Type | Duration | Start | Finish | Predecessors | Total slack | Free slack | Constraint | Resources | Work | Cost |
| --- | --- | --- | --- | --- | --- | --- | --- | --- | --- | --- | --- | --- | --- |
| 1 | 1 | **Strategic Plan for a DAP** |  | 185d | 2004-08-18 | 2005-05-19 |  | 0d |  |  |  | 2161.6h | 202,528 |
| 2 | 1.1 | **Activity 1 - Establish, Organise and Implement the Project Management Infrastructure** |  | 35d | 2004-08-18 | 2004-10-06 |  | 2d |  |  |  | 300h | 22,240 |
| 3 | 1.1.1 | Examine and Review Existing Background Documents |  | 8h | 2004-08-18 | 2004-08-31 |  | 18d |  |  | Christine Ardern; Sean Rickert | 16h | 2,080 |
| 4 | 1.1.2 | Particpate in Planning Sessions |  | 8h | 2004-08-20 | 2004-09-16 | 3SF+24h | 0d |  | start no earlier than 2004-08-20 | Fred Diers | 8h | 2,000 |
| 5 | 1.1.3 | Define Project Communication Protocols, Delivery Acceptance Criteria, and Report Structures |  | 4h | 2004-08-26 | 2004-08-26 | 4SF+40h | 176.5d | 12d |  | Fred Diers; Dhurjati Mueller | 8h | 1,000 |
| 6 | 1.1.4 | Establish Issue Escalation, Change Orders, Risk Identification |  | 16h | 2004-08-26 | 2004-09-16 | 5SF+16h | 164.5d |  | start no earlier than 2004-08-26 | Fred Diers; Dhurjati Mueller | 32h | 4,000 |
| 7 | 1.1.5 | Create & Submit Draft Interview Surveys/Interviewee Criteria |  | 16h | 2004-08-30 | 2004-09-07 | 4SF+64h | 171d |  | start no earlier than 2004-08-30 |  |  |  |
| 8 | 1.1.6 | **Project Work Plan** |  | 24.5d | 2004-09-01 | 2004-10-06 |  | 0d |  |  |  | 236h | 13,160 |
| 9 | 1.1.6.1 | Prepare a Draft Project Work Plan |  | 32h | 2004-09-02 | 2004-09-15 | 4FS-80h | 0d |  |  | Fred Diers; Dhurjati Mueller | 64h | 8,000 |
| 10 | 1.1.6.2 | Review and Update Project Work Plan with UNPOs Project Manger |  | 4h | 2004-09-16 | 2004-09-16 | 9 | 0d |  |  | Dhurjati Mueller; Fred Diers | 8h | 1,000 |
| 11 | 1.1.6.3 | Assign DAP Coordinators |  | 40h | 2004-09-01 | 2004-09-20 | 10FS-80h | 0d |  |  | UNPOs | 40h |  |
| 12 | 1.1.6.4 | Conduct Project Kick-off Meeting |  | 4h | 2004-09-23 | 2004-09-23 | 11FS+20h | 0d |  |  | Fred Diers; Christine Ardern; Sean Rickert; Jim Mernin; Dhurjati Mueller; WG-ARM Members; DAP Coordinators | 28h | 2,720 |
| 13 | 1.1.6.5 | Review Project Work Plan by WG-ARM 7 DAP Coordinators |  | 40h | 2004-09-23 | 2004-10-01 | 12FS-4h | 0d |  |  | WG-ARM Members; DAP Coordinators | 80h |  |
| 14 | 1.1.6.6 | Incorporate Project Plan Edits |  | 16h | 2004-10-04 | 2004-10-06 | 13 | 0d |  |  | Sean Rickert | 16h | 1,440 |
| 15 | 1.1.6.7 | Issue Final Project Work Plan | milestone | 0h | 2004-10-06 | 2004-10-06 | 14 | 150d |  |  | Fred Diers |  |  |
| 16 | 1.2 | **Activity 2 - Survey and Review Current Digital Records Practices, Procedures and Best Practices** |  | 50.62d | 2004-09-23 | 2004-12-08 |  | 51.38d |  |  |  | 544h | 38,008 |
| 17 | 1.2.1 | Schedule 30 Interviews based on Interviewee Criteria |  | 40h | 2004-09-23 | 2004-10-08 | 12 | 51.38d | 0d |  | WG-ARM Members; UNPOs; DAP Coordinators | 120h |  |
| 18 | 1.2.2 | Distribute Interview Surveys |  | 4h | 2004-10-08 | 2004-10-08 | 17 | 51.38d | 0d |  | WG-ARM Members; UNPOs; DAP Coordinators | 12h |  |
| 19 | 1.2.3 | Conduct Staff Interviews |  | 72h | 2004-10-11 | 2004-11-05 | 3FS+8h, 17, 18 | 51.38d | 0d |  | Christine Ardern [80%]; Sean Rickert [20%] | 72h | 11,088 |
| 20 | 1.2.4 | Gather Digital Records Representative Samplings |  | 80h | 2004-10-12 | 2004-11-05 | 19SS+8h | 55.5d | 5.88d |  | Christine Ardern [20%]; Sean Rickert [80%] | 80h | 8,480 |
| 21 | 1.2.5 | Review and Assess Formal and Operational Policies, Practices, Procedures and Approaches |  | 32h | 2004-11-08 | 2004-11-11 | 19, 3 | 51.38d | 0d |  | Christine Ardern [50%]; Sean Rickert | 48h | 5,600 |
| 22 | 1.2.6 | **Digital Records Process Analysis Report** |  | 15d | 2004-11-15 | 2004-12-08 |  | 51.38d |  |  |  | 212h | 12,840 |
| 23 | 1.2.6.1 | Create a Deliverable Acceptance Document (DAD) |  | 40h | 2004-11-15 | 2004-11-22 | 19, 20, 21FS+1h, 3FS+8h | 51.38d | 0d |  | Christine Ardern; Sean Rickert | 80h | 10,400 |
| 24 | 1.2.6.2 | Issue the Report and DAD to UNPOs Project Manager |  | 4h | 2004-11-22 | 2004-11-22 | 23 | 51.38d | 0d |  | Dhurjati Mueller; Fred Diers | 8h | 1,000 |
| 25 | 1.2.6.3 | Obtain WG-ARM review and edits |  | 36h | 2004-11-22 | 2004-12-01 | 24 | 51.38d | 0d |  | Dhurjati Mueller; WG-ARM Members; DAP Coordinators | 108h |  |
| 26 | 1.2.6.4 | Incorporate Edits and Issue Final Process Analysis Report |  | 16h | 2004-12-06 | 2004-12-08 | 25FS+24h | 51.38d |  |  | Sean Rickert | 16h | 1,440 |

| ID | WBS | Task | Duration | Start | Finish | Predecessors | Total slack | Resources | Work | Cost |
| --- | --- | --- | --- | --- | --- | --- | --- | --- | --- | --- |
| 27 | 1.3 | **Activity 3 - Inventory Digital Records Information Management Data Bases & Technical Platforms** | 41d | 2004-10-27 | 2005-01-04 |  | 0d |  | 384h | 34,640 |
| 28 | 1.3.1 | Conduct a Technology Infrastructure Study Through Selected Interivews | 64h | 2004-10-27 | 2004-11-17 | 14FS+112h | 0d | Jim Mernin | 64h | 10,880 |
| 29 | 1.3.2 | Conduct a Sampling of Digital Records Repository Formats | 80h | 2004-11-19 | 2004-12-06 | 28FS+8h | 0d | Jim Mernin [50%]; Sean Rickert | 96h | 9,920 |
| 30 | 1.3.3 | **UNPO Information Systems Technical Characteristics Report** | 15d | 2004-12-07 | 2005-01-04 |  | 0d |  | 224h | 13,840 |
| 31 | 1.3.3.1 | Create a Deliverable Acceptance Document (DAD) | 40h | 2004-12-07 | 2004-12-13 | 28, 29 | 0d | Jim Mernin; Sean Rickert | 80h | 10,400 |
| 32 | 1.3.3.2 | Issue the Report and DAD to UNPOs Project Manager | 8h | 2004-12-14 | 2004-12-14 | 31 | 0d | Dhurjati Mueller; Fred Diers | 16h | 2,000 |
| 33 | 1.3.3.3 | Obtain WG-ARM review and edits | 56h | 2004-12-15 | 2004-12-23 | 32 | 0d | WG-ARM Members; Dhurjati Mueller | 112h |  |
| 34 | 1.3.3.4 | Incorporate Edits and Issue Final UNPO Information Systems Technical Characteristics Report | 16h | 2005-01-03 | 2005-01-04 | 33 | 0d | Sean Rickert | 16h | 1,440 |
| 35 | 1.4 | **Activity 4 - Establish and Develop DAP Specifications, Requirements, and Standards** | 36.5d | 2005-01-05 | 2005-02-28 |  | 0d |  | 328h | 35,176 |
| 36 | 1.4.1 | Identify Digital Records Creation and Storage Strategies | 40h | 2005-01-05 | 2005-01-11 | 34 | 0d | Jim Mernin [80%]; Sean Rickert [20%] | 40h | 6,160 |
| 37 | 1.4.2 | Identify Metadata and Classification Requirements | 80h | 2005-01-12 | 2005-01-26 | 36 | 0d | Jim Mernin [20%]; Sean Rickert [80%] | 48h | 5,600 |
| 38 | 1.4.3 | Identify Best Approaches, Formats, and Data Structures for Long-term Preservation | 64h | 2005-01-27 | 2005-02-07 | 37 | 0d | Jim Mernin [60%]; Christine Ardern [20%]; Sean Rickert [20%] | 64h | 9,856 |
| 39 | 1.4.4 | **Prepare Administrative, Technical and Model Report detailing DAP Requirements** | 13.5d | 2005-02-08 | 2005-02-28 |  | 0d |  | 176h | 13,560 |
| 40 | 1.4.4.1 | Create a Deliverable Acceptance Document (DAD) | 40h | 2005-02-08 | 2005-02-15 | 36, 37, 38 | 0d | Jim Mernin [80%]; Christine Ardern [20%]; Sean Rickert | 80h | 10,400 |
| 41 | 1.4.4.2 | Issue the Report and DAD to UNPOs Project Manager | 4h | 2005-02-16 | 2005-02-16 | 40 | 0d | Dhurjati Mueller; Fred Diers | 8h | 1,000 |
| 42 | 1.4.4.3 | Obtain WG-ARM review and edits | 32h | 2005-02-16 | 2005-02-22 | 41 | 0d | WG-ARM Members; Dhurjati Mueller | 64h |  |
| 43 | 1.4.4.4 | Incorporate Edits and Issue DAP Final Functional Model Report | 24h | 2005-02-23 | 2005-02-28 | 42FS+8h | 0d | Sean Rickert | 24h | 2,160 |
| 44 | 1.5 | **Activity 5 - Prepare and Create a DAP Implementation Plan** | 16.5d | 2005-03-01 | 2005-03-23 |  | 0d |  | 138.4h | 13,360 |
| 45 | 1.5.1 | **Prepare a Draft DAP Implementation Plan** | 16.5d | 2005-03-01 | 2005-03-23 |  | 0d |  | 138.4h | 13,360 |
| 46 | 1.5.1.1 | Create a Deliverable Acceptance Document (DAD) | 64h | 2005-03-01 | 2005-03-11 | 26, 34, 43FS+8h | 0d | Jim Mernin [80%]; Christine Ardern [20%]; Sean Rickert [40%] | 70.4h | 9,920 |
| 47 | 1.5.1.2 | Issue Plan and DAD to UNPOs Project Manager | 4h | 2005-03-11 | 2005-03-11 | 46 | 0d | Dhurjati Mueller; Fred Diers | 8h | 1,000 |
| 48 | 1.5.1.3 | Review Draft Plan with WG-ARM | 4h | 2005-03-15 | 2005-03-15 | 47FS+8h | 0d | Dhurjati Mueller; Fred Diers | 8h | 1,000 |
| 49 | 1.5.1.4 | Obtain WG-ARM review and edits | 36h | 2005-03-15 | 2005-03-21 | 48 | 0d | WG-ARM Members | 36h |  |
| 50 | 1.5.1.5 | Incorporate Edits and Issue Final DAP Implementation Plan | 16h | 2005-03-22 | 2005-03-23 | 49 | 0d | Sean Rickert | 16h | 1,440 |

| ID | WBS | Task | Duration | Start | Finish | Predecessors | Total slack | Resources | Work | Cost |
| --- | --- | --- | --- | --- | --- | --- | --- | --- | --- | --- |
| 51 | 1.6 | **Activity 6 - Communicate and Market the DAP and Implementation Plan** | 24d | 2005-03-28 | 2005-04-28 |  | 0d |  | 237.6h | 29,288 |
| 52 | 1.6.1 | **Develop Presentation Materials** | 13d | 2005-03-28 | 2005-04-13 |  | 0d |  | 137.6h | 19,088 |
| 53 | 1.6.1.1 | Create a Deliverable Acceptance Document (DAD) | 64h | 2005-03-28 | 2005-04-06 | 50FS+16h | 0d | Christine Ardern [80%]; Sean Rickert [20%]; Jim Mernin [40%] | 89.6h | 14,208 |
| 54 | 1.6.1.2 | Submit Presentation Materials and DAD to UNPOs Project Manager | 8h | 2005-04-07 | 2005-04-07 | 53 | 0d | Dhurjati Mueller; Fred Diers | 16h | 2,000 |
| 55 | 1.6.1.3 | Incorporate Edits and Issue Final Presentation Materials | 32h | 2005-04-08 | 2005-04-13 | 54 | 0d | Sean Rickert | 32h | 2,880 |
| 56 | 1.6.2 | Make Presentations to UNPO Selected Groups (WG-ARM and the Task Force on Common Services) | 80h | 2005-04-15 | 2005-04-28 | 55FS+8h | 0d | Christine Ardern; Dhurjati Mueller [50%] | 100h | 10,200 |
| 57 | 1.7 | **Activity 7 - Prepare a DAP Implementation Work Plan (Phase 2)** | 15d | 2005-04-29 | 2005-05-19 |  | 0d |  | 229.6h | 29,816 |
| 58 | 1.7.1 | Create a Deliverable Acceptance Document (DAD) | 64h | 2005-04-29 | 2005-05-10 | 56 | 0d | Fred Diers [10%]; Christine Ardern [50%]; Sean Rickert; Jim Mernin [50%] | 134.4h | 18,240 |
| 59 | 1.7.2 | Issue and Review Phase 2 Implemenation Work Plan and DAD with UNPOs Project Manager | 24h | 2005-05-11 | 2005-05-13 | 58 | 0d | Fred Diers; Dhurjati Mueller | 48h | 6,000 |
| 60 | 1.7.3 | Incorporate Edits and Issue Final Phase 2 Implementation Work Plan | 24h | 2005-05-16 | 2005-05-18 | 59 | 0d | Fred Diers [10%]; Christine Ardern [10%]; Sean Rickert; Jim Mernin [10%] | 31.2h | 3,576 |
| 61 | 1.7.4 | Present Phase 2 Implementation Work Plan to WG-ARM | 8h | 2005-05-19 | 2005-05-19 | 60 | 0d | Fred Diers; WG-ARM Members | 16h | 2,000 |
