# DAP initiation

Schedule from MS Project, 2002-09-23 to 2003-02-20, A marks actual dates.
DAP Initiation
Common Services
steps needed to initiate project

## Calendars

- Standard: Mon-Fri 08:00-12:00, 13:00-17:00; Sat-Sun off. Exceptions (off unless hours are given): 2002-10-03 09:00-13:00, 14:00-18:00.

## Schedule

| ID | Task | Type | Duration | Start | Finish | Predecessors | Complete | Remaining | Baseline start | Baseline finish | Baseline duration | Total slack | Constraint |
| --- | --- | --- | --- | --- | --- | --- | --- | --- | --- | --- | --- | --- | --- |
| 1 | Finalize EOI |  | 3d | 2002-09-23 A | 2002-09-25 A |  | 100% |  | 2002-09-23 | 2002-09-25 | 3d |  | start no earlier than 2002-09-23 |
| 2 | Post EOI | milestone | 0d | 2002-09-25 A | 2002-09-25 A | 1 | 100% |  | 2002-09-25 | 2002-09-25 | 0d |  |  |
| 3 | EOI on website |  | 27d | 2002-09-25 | 2002-10-31 |  |  |  |  |  |  | 80d | start no earlier than 2002-09-25 |
| 4 | WGARM Finalize RFI |  | 6d | 2002-09-26 A | 2002-10-03 | 2 | 98% | 0.12d | 2002-09-26 | 2002-10-03 | 6d | 4d |  |
| 5 | UNPD to circulate RFI |  | 16d | 2002-10-10 | 2002-10-31 | 4 |  |  | 2002-10-04 | 2002-10-25 | 16d | 0d | finish no earlier than 2002-10-31 |
| 6 | RFI closed | milestone | 0d | 2002-10-31 | 2002-10-31 | 5 |  |  | 2002-10-25 | 2002-10-25 | 0d | 0d | finish no earlier than 2002-10-31 |
| 7 | Create RFP Shorlist |  | 10d | 2002-11-01 | 2002-11-14 | 6 |  |  | 2002-10-28 | 2002-11-08 | 10d | 0d |  |
| 8 | Finalize SOW |  | 5d | 2002-11-15 | 2002-11-21 | 7 |  |  | 2002-11-11 | 2002-11-15 | 5d | 0d |  |
| 9 | Finalize RFP |  | 10d | 2002-11-22 | 2002-12-05 | 8 |  |  | 2002-11-18 | 2002-11-29 | 10d | 0d |  |
| 10 | Issue RFP | milestone | 0d | 2002-12-05 | 2002-12-05 | 9 |  |  | 2002-11-29 | 2002-11-29 | 0d | 0d |  |
| 11 | RFP response time |  | 25d | 2002-12-06 | 2003-01-09 | 10 |  |  | 2002-12-02 | 2003-01-03 | 25d | 0d |  |
| 12 | RFP evaluation |  | 10d | 2003-01-10 | 2003-01-23 | 11 |  |  | 2003-01-06 | 2003-01-17 | 10d | 0d |  |
| 13 | Make recommendation |  | 5d | 2003-01-24 | 2003-01-30 | 12 |  |  | 2003-01-20 | 2003-01-24 | 5d | 0d |  |
| 14 | Negoitate contract |  | 15d | 2003-01-31 | 2003-02-20 | 13 |  |  | 2003-01-27 | 2003-02-14 | 15d | 0d |  |
| 15 | Project Start up | milestone | 0d | 2003-02-20 | 2003-02-20 | 14 |  |  | 2003-02-14 | 2003-02-14 | 0d | 0d |  |

Notes:
- 1: reviewed and approved by WGARM
- 2: UNPD to review and post
- 4: to be reviewed and finalized by WGARM
- 5: UNPD will distribute RFI to all interested vendors responding to EOI
- 7: review and evaluate RFI responses
- 8: Incorporate RFI responses into SOW, Review and approve SOW by WGARM
- 9: UNPD and Legal activities
- 12: Review and evaluate RFP responses, make selection and recommendation
- 13: submit to UN review committee
- 14: UN Legal activities
- 15: Vender contracted
