# DAP start up

Schedule from MS Project, 2002-11-28 to 2003-09-30.
Unicef

## Calendars

- Standard: Mon-Fri 08:00-12:00, 13:00-17:00; Sat-Sun off.

## Schedule

| ID | Task | Type | Duration | Start | Finish | Predecessors | Baseline start | Baseline finish | Baseline duration | Total slack | Constraint |
| --- | --- | --- | --- | --- | --- | --- | --- | --- | --- | --- | --- |
| 1 | Release of RFP |  | 1d | 2002-11-28 | 2002-11-28 |  | 2002-11-28 | 2002-11-28 | 1d | 0d | start no earlier than 2002-11-28 |
| 2 | RFP response time |  | 30d | 2002-11-29 | 2003-01-09 | 1 | 2002-11-29 | 2003-01-09 | 30d | 0d |  |
| 3 | vender questions submitted |  | 10d | 2002-11-28 | 2002-12-11 |  | 2002-11-28 | 2002-12-11 | 10d | 209d | start no earlier than 2002-11-28 |
| 4 | RFP closing | milestone | 0d | 2003-01-09 | 2003-01-09 | 2 | 2003-01-09 | 2003-01-09 | 0d | 0d | start no earlier than 2003-01-09 |
| 5 | RFP evaluation |  | 10d | 2003-01-10 | 2003-01-23 | 4 | 2003-01-10 | 2003-01-23 | 10d | 0d |  |
| 6 | vendor recommendation |  | 5d | 2003-01-24 | 2003-01-30 | 5 | 2003-01-24 | 2003-01-30 | 5d | 0d |  |
| 7 | negotiate contract |  | 15d | 2003-01-31 | 2003-02-20 | 6 | 2003-01-31 | 2003-02-20 | 15d | 0d |  |
| 8 | vendor start up | milestone | 0d | 2003-02-20 | 2003-02-20 | 7 | 2003-02-20 | 2003-02-20 | 0d | 0d |  |
| 9 | initial meeting with PM |  | 5d | 2003-02-21 | 2003-02-27 | 8 | 2003-02-21 | 2003-02-27 | 5d | 0d |  |
| 10 | vendor completes Deliverable 1 |  | 10d | 2003-02-28 | 2003-03-13 | 9 | 2003-02-28 | 2003-03-13 | 10d | 0d |  |
| 11 | vendor completes deliverable 2-5 |  | 121d | 2003-03-14 | 2003-08-29 | 10 | 2003-03-14 | 2003-08-29 | 121d | 0d |  |
| 12 | vendor completes deliverable 6-7 |  | 22d | 2003-09-01 | 2003-09-30 | 11 | 2003-09-01 | 2003-09-30 | 22d | 0d |  |
